# ProjectBSS

Schedule from MS Project, 2003-01-10 to 2004-03-02, A marks actual dates.
CERN

## Calendars

- Standard: Mon-Fri 08:00-12:00, 13:00-17:00; Sat-Sun off.

## Resources

| Resource |
| --- |
| Sonia |
| Neil |
| Raphael |
| Andrea |
| Jack |
| Doug |
| Ian |
| John |
| Curt |
| CERN WS |
| OSLO WS |
| Iourii |
| Adrian |
| Mario |
| Metrology |
| Survey |
| TA1 |
| Daniel |
| CERN based |

## Schedule

| ID | WBS | Task | Type | Duration | Start | Finish | Predecessors | Complete | Remaining | Baseline start | Baseline finish | Baseline duration | Total slack | Free slack | Constraint | Resources | Work | Actual work |
| --- | --- | --- | --- | --- | --- | --- | --- | --- | --- | --- | --- | --- | --- | --- | --- | --- | --- | --- |
| 1 | 1 | **Barrel Support Structure** |  | 298d | 2003-01-10 A | 2004-03-02 |  | 23% | 229.26d |  |  |  | 0d |  |  |  | 14211.2h | 2040.8h |
| 3 | 1.1 | **Barrel Support Structure design and test issues** |  | 68d | 2003-01-22 A | 2003-04-25 |  | 82% | 12.14d | 2003-01-22 | 2003-04-25 | 68d | 222d |  |  |  | 707.2h | 607.2h |
| 4 | 1.1.1 | testing samples for bending strength |  | 20d | 2003-02-17 A | 2003-03-14 A |  | 100% |  | 2003-02-17 | 2003-03-14 | 20d |  |  |  | Andrea; Sonia | 320h | 320h |
| 5 | 1.1.2 | pre-develop insert screw/washer for IC |  | 30d | 2003-01-22 A | 2003-03-04 A |  | 100% |  | 2003-01-22 | 2003-03-04 | 30d |  |  |  | Neil [20%] | 48h | 48h |
| 6 | 1.1.3 | verify design of rails |  | 25d | 2003-03-03 A | 2003-04-04 A |  | 100% |  | 2003-03-03 | 2003-04-04 | 25d |  |  | start no earlier than 2003-03-03 | Raphael [30%] | 60h | 60h |
| 7 | 1.1.4 | verify strength or ears |  | 6d | 2003-04-07 A | 2003-04-14 A | 6 | 100% |  | 2003-04-07 | 2003-04-14 | 6d |  |  |  | Andrea [80%] | 38.4h | 38.4h |
| 8 | 1.1.5 | review requirements on strength and positional tolerance |  | 7d | 2003-03-03 A | 2003-03-11 A |  | 100% |  | 2003-03-03 | 2003-03-11 | 7d |  |  | start no earlier than 2003-03-03 | Andrea [10%] | 5.6h | 5.6h |
| 9 | 1.1.6 | review design and modification of jigs |  | 15d | 2003-03-12 A | 2003-04-01 A | 8 | 100% |  | 2003-03-12 | 2003-04-01 | 15d |  |  |  | Andrea [10%]; John [10%]; Curt [30%] | 58.4h | 58.4h |
| 10 | 1.1.7 | finalize F&C step document |  | 3d | 2003-03-12 A | 2003-03-14 A | 8 | 100% |  | 2003-03-12 | 2003-03-14 | 3d |  |  |  | Andrea [80%] | 19.2h | 19.2h |
| 11 | 1.1.8 | QCP document revision and approval |  | 5d | 2003-03-14 A | 2003-03-20 A | 10 | 100% |  | 2003-03-14 | 2003-03-20 | 5d |  |  |  | Andrea [80%] | 32h | 32h |
| 12 | 1.1.9 | Acceptance at Cern procedure document |  | 4d | 2003-03-18 A | 2003-03-21 A | 11 | 100% |  | 2003-03-18 | 2003-03-21 | 4d |  |  |  | Andrea [80%] | 25.6h | 25.6h |
| 13 | 1.1.10 | Define load test and procedure for Protvino |  | 10d | 2003-03-24 | 2003-04-04 | 12 |  |  | 2003-03-24 | 2003-04-04 | 10d | 213d | 0d |  | Andrea [80%] | 64h |  |
| 14 | 1.1.11 | design of SCT rails |  | 15d | 2003-04-07 | 2003-04-25 | 13 |  |  | 2003-04-07 | 2003-04-25 | 15d | 213d |  |  | Andrea [30%] | 36h |  |
| 16 | 1.2 | **BSS assembly rig** |  | 279d | 2003-01-10 A | 2004-02-05 |  | 41% | 165.11d | 2003-01-10 | 2003-12-17 | 243d | 19d |  |  |  | 3888h | 1433.6h |
| 17 | 1.2.1 | Design, drawings, calculations and procurement |  | 112d | 2003-01-10 A | 2003-06-16 |  | 80% | 22.4d | 2003-01-10 | 2003-06-16 | 112d | 113.5d | 0d | finish no earlier than 2003-06-16 | Andrea; Ian | 1792h | 1433.6h |
| 18 | 1.2.2 | Procedure for target mounting and pre-alignment of assembly rig |  | 10d | 2003-06-03 | 2003-06-16 | 17FS-2w |  |  | 2003-06-03 | 2003-06-16 | 10d | 177d |  |  | Jack; Neil; Doug | 240h |  |
| 19 | 1.2.3 | Acceptance of assembly rig components |  | 1w | 2003-06-17 | 2003-06-23 | 17 |  |  | 2003-06-17 | 2003-06-23 | 1w | 113.5d | 0d |  | Neil | 40h |  |
| 20 | 1.2.4 | Design of mechanical interface rails-rig |  | 5d | 2003-06-17 | 2003-06-23 | 17 |  |  | 2003-06-17 | 2003-06-19 | 3d | 142d | 0d |  | Raphael; Neil | 80h |  |
| 21 | 1.2.5 | Manufacturing of mechanical interfaces |  | 4w | 2003-06-24 | 2003-07-21 | 20 |  |  | 2003-06-20 | 2003-07-17 | 4w | 152d |  |  | Neil; CERN WS | 320h |  |
| 22 | 1.2.6 | Manufacturing of rails and contract follow up |  | 6w | 2003-06-24 | 2003-08-04 | 20 |  |  | 2003-06-20 | 2003-07-31 | 6w | 142d |  |  | Neil; OSLO WS | 480h |  |
| 23 | 1.2.7 | Pre-assembly in 154 |  | 1.5d | 2003-06-24 | 2003-06-25 | 19 |  |  | 2003-06-24 | 2003-07-03 | 1.5w | 128.5d | 0d |  | Jack; Neil; Doug; CERN based | 48h |  |
| 24 | 1.2.8 | Tailoring of mechanical adjustments and interfaces |  | 4w | 2003-06-25 | 2003-07-23 | 23 |  |  | 2003-07-03 | 2003-07-31 | 4w | 159.5d |  |  | Jack; Iourii; Doug | 480h |  |
| 25 | 1.2.9 | Alignment of assembly rig structure (only for BSS parts acceptance) |  | 3d | 2003-07-07 | 2003-07-09 | 23FS+1w, 43 |  |  | 2003-07-10 | 2003-07-15 | 3d | 126d | 0d |  | Survey; Jack; Doug; CERN based | 96h |  |
| 26 | 1.2.10 | Analysis of data |  | 2d | 2003-07-10 | 2003-07-11 | 25 |  |  | 2003-07-15 | 2003-07-17 | 2d | 126d | 0d |  | Jack; Doug | 32h |  |
| 27 | 1.2.11 | dismount and transport to SR |  | 3d | 2003-08-25 | 2003-08-27 | 26FS+6w |  |  | 2003-08-28 | 2003-09-02 | 3d | 126d | 0d |  | Neil; Adrian | 48h |  |
| 28 | 1.2.12 | Re-alignment of assembly rig and mount additional references |  | 3d | 2003-08-28 | 2003-09-01 | 27 |  |  | 2003-09-02 | 2003-09-05 | 3d | 126d | 0d |  | Survey; Jack; Doug | 72h |  |
| 29 | 1.2.13 | Assembly in SR |  | 5d | 2003-09-02 | 2003-09-08 | 28 |  |  | 2003-09-05 | 2003-09-12 | 5d | 126d |  |  | Neil; Jack; Doug; CERN based | 160h |  |
| 30 | 1.2.14 | Assembly of BSS rig required to be ready (at latest for cylinder acceptance) | milestone | 0d | 2003-09-03 | 2003-09-03 | 49 |  |  | 2003-07-23 | 2003-07-23 | 0d | 120d |  |  |  |  |  |
| 31 | 1.2.15 | Assembly of BSS rig required to be ready (at latest for BSS full assembly) | milestone | 0d | 2004-02-05 | 2004-02-05 | 96SF |  |  | 2003-12-17 | 2003-12-17 | 0d | 19d |  |  |  |  |  |

| ID | WBS | Task | Type | Duration | Start | Finish | Predecessors | Baseline start | Baseline finish | Baseline duration | Total slack | Free slack | Constraint | Resources | Work |
| --- | --- | --- | --- | --- | --- | --- | --- | --- | --- | --- | --- | --- | --- | --- | --- |
| 33 | 1.3 | **Faraday shield** |  | 45d | 2003-06-02 | 2003-08-01 |  | 2003-06-02 | 2003-08-01 | 45d | 152d |  |  |  | 1080h |
| 34 | 1.3.1 | Finalize faraday cage design issues |  | 15d | 2003-06-02 | 2003-06-20 |  | 2003-06-02 | 2003-06-20 | 15d | 143d | 0d | start no earlier than 2003-06-02 | Jack; Doug; Curt | 360h |
| 35 | 1.3.2 | Design electrical connections |  | 5d | 2003-06-23 | 2003-06-27 | 34 | 2003-06-23 | 2003-06-27 | 5d | 143d | 0d |  | Curt | 40h |
| 36 | 1.3.3 | Manufacturing drawings of electrical connections |  | 5d | 2003-06-30 | 2003-07-04 | 35 | 2003-06-30 | 2003-07-04 | 5d | 143d | 0d |  | Curt; Jack; Doug | 120h |
| 37 | 1.3.4 | Manufacturing electrical connections and follow up |  | 20d | 2003-07-07 | 2003-08-01 | 36 | 2003-07-07 | 2003-08-01 | 20d | 143d |  |  | Jack; CERN WS; Doug | 480h |
| 38 | 1.3.5 | Jig manufacturing for drilling of tapped holes, drilling |  | 5d | 2003-07-07 | 2003-07-11 | 36 | 2003-07-07 | 2003-07-11 | 5d | 158d |  | start no earlier than 2003-06-08 | Neil; Adrian | 80h |
| 40 | 1.4 | **Inner cylinder** |  | 87d | 2003-05-26 | 2003-09-23 |  | 2003-05-26 | 2003-08-06 | 53d | 115d |  |  |  | 1840h |
| 41 | 1.4.1 | Initial design concepts for inspection fixture (see also ass. rig flanges) |  | 15d | 2003-05-26 | 2003-06-13 |  | 2003-05-26 | 2003-05-30 | 5d | 131d | 0d | start no earlier than 2003-05-26 | Jack; Doug; Neil | 360h |
| 42 | 1.4.2 | Discussions with CERN Survey group, finalize metrology procedure (both IC&OC) |  | 5d | 2003-06-16 | 2003-06-20 | 41 | 2003-06-10 | 2003-06-16 | 5d | 126d | 0d | start no earlier than 2003-06-10 | Jack; Doug; Neil; CERN based | 160h |
| 43 | 1.4.3 | Evaluate and Modify Inner Cylinder Support fixture from BSS assembly rig |  | 10d | 2003-06-23 | 2003-07-04 | 42 | 2003-06-10 | 2003-06-16 | 5d | 126d | 0d | start no earlier than 2003-06-10 | Jack; Doug; Neil; Andrea [20%]; CERN based | 336h |
| 44 | 1.4.4 | Final design and drawings |  | 10d | 2003-07-10 | 2003-07-23 | 43, 25 | 2003-06-17 | 2003-06-30 | 10d | 132d | 0d |  | Jack; Mario; Doug | 240h |
| 45 | 1.4.5 | Machining of fixtures |  | 15d | 2003-07-24 | 2003-08-13 | 44 | 2003-07-01 | 2003-07-21 | 15d | 132d | 0d |  | CERN WS; Jack; Doug | 360h |
| 46 | 1.4.6 | Certification of fixtures |  | 3d | 2003-08-14 | 2003-08-18 | 45 | 2003-07-22 | 2003-07-24 | 3d | 141d |  |  | Metrology; Jack; Doug | 72h |
| 47 | 1.4.7 | delivery IC at Cern | milestone | 0d | 2003-08-26 | 2003-08-26 | 108 | 2003-06-30 | 2003-06-30 | 0d | 136d |  |  |  |  |
| 48 | 1.4.8 | Standard acceptance measurements |  | 5d | 2003-08-26 | 2003-09-01 | 108 | 2003-06-30 | 2003-07-04 | 5d | 119d | 0d |  | Neil | 40h |
| 49 | 1.4.9 | Photogrammetry of Inner Cylinder and data analysis |  | 2d | 2003-09-02 | 2003-09-03 | 48, 45 | 2003-07-22 | 2003-07-23 | 2d | 119d | 0d |  | Survey; Andrea | 32h |
| 50 | 1.4.10 | Limit date for formal acceptance | milestone | 0d | 2003-09-23 | 2003-09-23 | 108FS+4.2w | 2003-07-28 | 2003-07-28 | 0d | 115d |  |  |  |  |
| 51 | 1.4.11 | Install faraday shield |  | 10d | 2003-09-04 | 2003-09-17 | 49 | 2003-07-24 | 2003-08-06 | 10d | 119d |  |  | Jack; Doug; CERN based | 240h |
| 53 | 1.5 | **Outer cylinder** |  | 73d | 2003-05-26 | 2003-09-03 |  | 2003-05-26 | 2003-08-13 | 58d | 129d |  |  |  | 1544h |
| 54 | 1.5.1 | Initial design concepts for inspection fixture |  | 15d | 2003-05-26 | 2003-06-13 |  | 2003-05-26 | 2003-05-30 | 5d | 187d |  | start no earlier than 2003-05-26 | Jack; Doug; Neil | 360h |
| 55 | 1.5.2 | Final design and drawings |  | 10d | 2003-06-23 | 2003-07-04 | 42 | 2003-06-17 | 2003-06-30 | 10d | 140d | 0d | start no earlier than 2003-06-17 | Jack; Mario; Doug | 240h |
| 56 | 1.5.3 | Machining of fixtures |  | 15d | 2003-07-07 | 2003-07-25 | 55 | 2003-07-01 | 2003-07-21 | 15d | 140d | 0d | start no earlier than 2003-07-01 | CERN WS; Jack; Doug | 360h |
| 57 | 1.5.4 | Certification of fixtures |  | 3d | 2003-07-28 | 2003-07-30 | 56 | 2003-07-22 | 2003-07-24 | 3d | 154d |  |  | Metrology; Jack; Doug; CERN based | 96h |
| 58 | 1.5.5 | delivery OC at Cern | milestone | 0d | 2003-08-04 | 2003-08-04 | 109 | 2003-06-30 | 2003-06-30 | 0d | 129d | 0d |  |  |  |
| 59 | 1.5.6 | Standard acceptance measurements |  | 3d | 2003-08-04 | 2003-08-06 | 58 | 2003-06-30 | 2003-07-02 | 3d | 129d | 0d |  | Neil | 24h |
| 60 | 1.5.7 | trial assembly 2 halves outer cylinder |  | 3d | 2003-08-07 | 2003-08-11 | 59 | 2003-07-03 | 2003-07-07 | 3d | 129d | 0d |  | Neil; Jack; Doug | 72h |
| 61 | 1.5.8 | Photogrammetry of Outer Cylinder and data analysis |  | 2d | 2003-08-12 | 2003-08-13 | 56, 60 | 2003-07-22 | 2003-07-23 | 2d | 129d | 0d |  | Survey; Andrea | 32h |
| 62 | 1.5.9 | Limit date for formal acceptance | milestone | 0d | 2003-09-01 | 2003-09-01 | 109FS+4.2w | 2003-07-28 | 2003-07-28 | 0d | 131d |  |  |  |  |
| 63 | 1.5.10 | install farady shield |  | 15d | 2003-08-14 | 2003-09-03 | 61 | 2003-07-24 | 2003-08-13 | 15d | 129d |  |  | Jack; Doug; CERN based | 360h |

Notes:
- 43: This task describes using the inner cylinder "brake shoe" assembly to hold the inner / cylinder for acceptance measurements. This will require measuring the parts and / modifying them if needed.

| ID | WBS | Task | Type | Duration | Start | Finish | Predecessors | Baseline start | Baseline finish | Baseline duration | Total slack | Free slack | Constraint | Resources | Work |
| --- | --- | --- | --- | --- | --- | --- | --- | --- | --- | --- | --- | --- | --- | --- | --- |
| 66 | 1.6 | **End-frames** |  | 136d | 2003-07-30 | 2004-02-04 |  | 2003-06-24 | 2003-12-16 | 126d | 19d |  |  |  | 2560h |
| 67 | 1.6.1 | Tailoring of mechanical arm for standard measurements, tests on sector prototype |  | 10w | 2003-08-06 | 2003-10-15 | 77SF | 2003-06-24 | 2003-09-02 | 10w | 100d | 0d | start no earlier than 2003-06-20 | Neil [20%]; Adrian | 200h |
| 68 | 1.6.2 | Contacts with CERN Survey group (and procurement of additional targets) |  | 3d | 2003-08-06 | 2003-08-08 | 67SS | 2003-06-25 | 2003-06-27 | 3d | 142d | 0d | start no earlier than 2003-06-25 | Neil; Jack; Doug; CERN based | 96h |
| 69 | 1.6.3 | Finalize procedure for photogrammetry acceptance |  | 5d | 2003-08-11 | 2003-08-15 | 68 | 2003-06-30 | 2003-07-04 | 5d | 142d |  |  | Jack; Doug; Neil | 120h |
| 70 | 1.6.4 | Conceptual design of fixture |  | 10d | 2003-08-21 | 2003-09-04 | 71SF | 2003-07-09 | 2003-07-23 | 10d | 129d |  | start no earlier than 2003-06-26 | Jack; Doug | 160h |
| 71 | 1.6.5 | Final design and drawings |  | 7d | 2003-09-04 | 2003-09-15 | 72SF | 2003-07-23 | 2003-08-01 | 7d | 122d | 0d |  | Mario | 56h |
| 72 | 1.6.6 | Machining of fixtures |  | 4w | 2003-09-15 | 2003-10-13 | 73SF | 2003-08-01 | 2003-08-29 | 4w | 102d | 0d |  | CERN WS; Jack; Doug | 480h |
| 73 | 1.6.7 | Certification of fixtures |  | 2d | 2003-10-13 | 2003-10-14 | 76SF | 2003-08-29 | 2003-09-02 | 2d | 100d | 0d |  | Metrology; Jack; Doug | 48h |
| 75 | 1.6.8 | inspection of first end-frame at Technologiya |  | 5d | 2003-07-30 | 2003-08-05 |  | 2003-07-30 | 2003-08-05 | 5d | 150d |  | start no earlier than 2003-07-30 | John; Jack; Doug | 120h |
| 76 | 1.6.9 | delivery of first end-frame at Cern | milestone | 0d | 2003-10-14 | 2003-10-14 | 110 | 2003-09-02 | 2003-09-02 | 0d | 75d | 0d |  |  |  |
| 77 | 1.6.10 | Standard acceptance measurements |  | 5d | 2003-10-15 | 2003-10-21 | 76 | 2003-09-02 | 2003-09-08 | 5d | 75d | 0d |  | Neil; Jack; Doug | 120h |
| 78 | 1.6.11 | Photogrammetry and analysis of data |  | 5d | 2003-10-22 | 2003-10-28 | 77 | 2003-09-09 | 2003-09-15 | 5d | 75d | 0d |  | Jack; Doug; Survey; CERN based | 160h |
| 79 | 1.6.12 | install farady shield |  | 15d | 2003-10-29 | 2003-11-18 | 78 | 2003-09-16 | 2003-09-29 | 10d | 75d |  |  | Jack; Doug; CERN based | 360h |
| 80 | 1.6.13 | delivery of second end-frame at Cern | milestone | 0d | 2003-12-31 | 2003-12-31 | 111 | 2003-11-19 | 2003-11-19 | 0d | 0d |  |  |  |  |
| 81 | 1.6.14 | Standard acceptance measurements |  | 5d | 2004-01-01 | 2004-01-07 | 80 | 2003-11-19 | 2003-11-25 | 5d | 0d |  |  | Neil; Jack; Doug | 120h |
| 82 | 1.6.15 | Photogrammetry and analysis of data |  | 5d | 2004-01-08 | 2004-01-14 | 81 | 2003-11-26 | 2003-12-02 | 5d | 0d |  |  | Jack; Doug; Survey; CERN based | 160h |
| 83 | 1.6.16 | install farady shield |  | 15d | 2004-01-15 | 2004-02-04 | 82 | 2003-12-03 | 2003-12-16 | 10d | 0d |  |  | Jack; Doug; CERN based | 360h |
| 85 | 1.7 | **BSS Structure – Assemble, align and bond BSS spool on Assembly Rig** |  | 79d | 2003-11-13 | 2004-03-02 |  | 2003-09-24 | 2004-01-06 | 75d | 0d |  |  |  | 2472h |
| 86 | 1.7.1 | Finalize bonding procedure for inner cylinder |  | 20d | 2004-01-08 | 2004-02-05 | 96SF | 2003-11-19 | 2003-12-17 | 20d | 19d |  | start no earlier than 2003-05-26 | Neil [30%] | 48h |
| 87 | 1.7.2 | Formalize procedure for photogrammetry and alignment of spool on assembly rig |  | 7.5d | 2003-12-04 | 2003-12-16 | 88SF | 2003-10-15 | 2003-10-27 | 7.5d | 56d |  |  | Jack; Doug | 120h |
| 88 | 1.7.3 | Procure additional targets (spherical) via Survey group |  | 10d | 2003-12-16 | 2004-02-05 | 96SF | 2003-10-27 | 2003-12-17 | 10d | 19d | 0d |  | Jack; Doug [10%] | 16h |
| 89 | 1.7.4 | Develop in house monitoring system and data analysis |  | 20d | 2004-01-08 | 2004-02-05 | 96SF | 2003-11-19 | 2003-12-17 | 20d | 19d |  |  | Neil [30%]; Jack; Doug | 368h |
| 90 | 1.7.5 | Design adjustable supports according to ID requirements |  | 20d | 2003-11-13 | 2003-12-11 | 91SF | 2003-09-24 | 2003-10-22 | 20d | 59d |  |  | Raphael [20%]; Andrea [20%] | 64h |
| 91 | 1.7.6 | Make prototype and test adjustable supports |  | 20d | 2003-12-11 | 2004-01-08 | 92SF | 2003-10-22 | 2003-11-19 | 20d | 39d | 0d |  | TA1; Raphael [30%] | 208h |
| 92 | 1.7.7 | Manufacture series of supports |  | 20d | 2004-01-08 | 2004-02-05 | 96SF | 2003-11-19 | 2003-12-17 | 20d | 19d | 0d |  | CERN WS; Jack; Doug | 480h |
| 93 | 1.7.8 | Produce and test special washers for screw connection |  | 20d | 2004-01-08 | 2004-02-05 | 96SF | 2003-11-19 | 2003-12-17 | 20d | 19d |  |  | Neil [30%]; Adrian | 208h |
| 94 | 1.7.9 | Design and produce spacer bars for end-frame pre-alignement |  | 20d | 2004-01-08 | 2004-02-05 | 96SF | 2003-12-10 | 2003-12-17 | 5d | 19d |  |  | Neil; Adrian | 320h |
| 95 | 1.7.10 | Drilling of injection holes into inner cylinder |  | 3d | 2004-02-02 | 2004-02-05 | 96SF | 2003-12-12 | 2003-12-17 | 3d | 19d |  |  | Neil | 24h |
| 96 | 1.7.11 | Dry assembly and alignment BSS end-frames and inner cylinder on assembly rig |  | 5d | 2004-02-05 | 2004-02-11 | 83 | 2003-12-17 | 2003-12-23 | 5d | 0d |  |  | Jack; Doug; Neil; CERN based | 160h |
| 97 | 1.7.12 | Bonding |  | 5d | 2004-02-12 | 2004-02-18 | 96 | 2003-12-24 | 2003-12-30 | 5d | 0d |  |  | Jack; Doug; Neil; CERN based | 160h |
| 98 | 1.7.13 | Alignment check |  | 3d | 2004-02-19 | 2004-02-23 | 97 | 2003-12-31 | 2004-01-02 | 3d | 0d |  |  | Jack; Doug; Neil; Survey; CERN based | 120h |
| 99 | 1.7.14 | Trial mount of outer cylinder |  | 2d | 2004-02-23 | 2004-02-25 | 98 | 2004-01-05 | 2004-01-06 | 2d | 0d |  |  | Jack; Doug; Neil; CERN based | 48h |
| 100 | 1.7.15 | Drill holes and added electrical contacts between end frames and inner cylinder |  | 2d | 2004-02-26 | 2004-02-27 | 99 |  |  |  | 0d |  |  | Jack; Neil; Doug; CERN based | 64h |
| 101 | 1.7.16 | Connect inner cylinder faraday shield to end frames |  | 2d | 2004-03-01 | 2004-03-02 | 100 |  |  |  | 0d |  |  | Jack; Neil; Doug; CERN based | 64h |
| 102 | 1.7.17 | BBS spool complete | milestone | 0d | 2004-03-02 | 2004-03-02 | 101 | 2004-01-06 | 2004-01-06 | 0d | 0d |  |  |  |  |

| ID | WBS | Task | Type | Duration | Start | Finish | Baseline start | Baseline finish | Baseline duration | Total slack | Free slack | Constraint | Resources | Work |
| --- | --- | --- | --- | --- | --- | --- | --- | --- | --- | --- | --- | --- | --- | --- |
| 104 | 1.8 | **Delivery schedule** |  | 108d | 2003-08-04 | 2003-12-31 | 2003-01-22 | 2003-11-19 | 215d | 44d |  |  |  | 120h |
| 106 | 1.8.1 | inspection of first end-frame at Technologiya |  | 5d | 2003-08-04 | 2003-08-08 | 2003-07-30 | 2003-08-04 | 3.33d | 147d |  | start no earlier than 2003-08-04 | John; Jack; Doug | 120h |
| 108 | 1.8.2 | delivery of Inner Cylinder to Cern | milestone | 0d | 2003-08-26 | 2003-08-26 | 2003-06-30 | 2003-06-30 | 0d | 115d | 0d | start no earlier than 2003-08-26 |  |  |
| 109 | 1.8.3 | delivery of Outer Cylinder to Cern | milestone | 0d | 2003-08-04 | 2003-08-04 | 2003-06-30 | 2003-06-30 | 0d | 129d | 0d | start no earlier than 2003-08-04 |  |  |
| 110 | 1.8.4 | delivery of first End-Frame to Cern | milestone | 0d | 2003-10-14 | 2003-10-14 | 2003-09-02 | 2003-09-02 | 0d | 75d | 0d | finish no earlier than 2003-10-14 |  |  |
| 111 | 1.8.5 | delivery of second End-Frame to Cern | milestone | 0d | 2003-12-31 | 2003-12-31 | 2003-11-19 | 2003-11-19 | 0d | 0d |  | finish no earlier than 2003-12-31 |  |  |
